# PROGRAMACION

Schedule from MS Project, 2009-09-01 to 2010-04-28, costs in S..

## Calendars

- Estándar: Mon-Sun 08:00-12:00, 13:00-17:00.

## Schedule

| ID | WBS | Task | Type | Duration | Start | Finish | Predecessors | Total slack | Free slack | Constraint | Cost |
| --- | --- | --- | --- | --- | --- | --- | --- | --- | --- | --- | --- |
| 1 | 1 | INICIO | milestone | 0d | 2009-09-01 | 2009-09-01 |  | 0d |  | start no earlier than 2009-09-01 |  |
| 2 | 2 | **MANTENIMIENTO DE LA CARRETERA PUNO - ILAVE** |  | 240d | 2009-09-01 | 2010-04-28 |  | 0d |  |  | 13,121,445.85 |
| 3 | 2.1 | **OBRAS PRELIMINARES** |  | 240d | 2009-09-01 | 2010-04-28 |  | 0d |  |  | 463,566.44 |
| 4 | 2.1.1 | MOVILIZACION Y DESMOVILIZACION DE EQUIPOS |  | 30d | 2009-09-01 | 2010-04-28 | 1 | 0d |  | start no earlier than 2007-04-02 | 289,511.3 |
| 5 | 2.1.2 | MANTENIMIENTO DE TRANSITO Y SEGURIDAD VIAL : PROCEDIMIENTO PARA MAQUINARIA EN MOVIMIENTO ( PAVIMENTOS) |  | 226d | 2009-09-15 | 2010-04-28 | 4SS+8d | 0d |  | start no earlier than 2009-09-15 | 172,504.19 |
| 6 | 2.1.3 | ACCESO A CANTERAS, DME Y FUENTES DE AGUA |  | 1d | 2009-09-06 | 2009-09-06 | 4SS+5d | 22d | 0d |  | 1,550.95 |
| 7 | 2.2 | **PAVIMENTOS** |  | 227d | 2009-09-14 | 2010-04-28 |  | 0d |  |  | 12,315,781 |
| 8 | 2.2.1 | RIEGO DE LIGA |  | 110d | 2009-09-18 | 2010-04-28 | 10FS-70d | 0d |  | start no earlier than 2009-09-18 | 287,014 |
| 9 | 2.2.2 | TRATAMIENTO SUPERFICIAL BICAPA |  | 127d | 2009-09-30 | 2010-04-28 | 8FS-247d | 0d |  | start no earlier than 2009-09-30 | 715,958 |
| 10 | 2.2.3 | BASE RECICLADA CON EMULSION |  | 64d | 2009-09-14 | 2009-11-16 |  | 10d | 0d | start no earlier than 2009-09-14 | 1,816,704 |
| 11 | 2.2.4 | EMULSION |  | 127d | 2009-09-14 | 2010-04-12 | 10SS | 16d |  | start no earlier than 2009-09-14 | 9,490,386 |
| 12 | 2.2.5 | SELLADO DE FISURAS MODERADAS Y SEVERAS |  | 1d | 2009-09-14 | 2009-09-14 | 6 | 226d |  | start no earlier than 2009-09-14 | 5,719 |
| 13 | 2.3 | **OBRAS DE ARTE Y DRENAJE** |  | 17d | 2009-09-09 | 2009-09-25 |  | 198d |  |  | 23,600.82 |
| 14 | 2.3.1 | LIMPIEZA DE ALCANTARILLAS |  | 8d | 2009-09-09 | 2009-09-16 |  | 198d | 0d | start no earlier than 2009-09-09 | 6,154.64 |
| 15 | 2.3.2 | LIMPIEZA DE CUNETAS |  | 1d | 2009-09-17 | 2009-09-17 | 14 | 198d | 0d |  | 274.18 |
| 16 | 2.3.3 | LIMPIEZA DE CAUCES |  | 8d | 2009-09-18 | 2009-09-25 | 15 | 198d | 7d |  | 17,172 |
| 17 | 2.4 | **TRANSPORTES** |  | 211d | 2009-09-30 | 2010-04-28 |  | 0d |  |  | 151,642.58 |
| 18 | 2.4.1 | TRANSPORTE DE ELIMINACION DE MATERIAL EXCEDENTE PARA D <= 1KM |  | 17d | 2009-10-03 | 2009-10-19 | 14, 15, 16 | 191d |  | start no earlier than 2009-10-03 | 2,789.42 |
| 19 | 2.4.2 | TRANSPORTE DE ELIMINACION DE MATERIAL EXCEDENTE PARA D > 1KM |  | 17d | 2009-10-03 | 2009-10-19 | 14, 15, 16 | 191d |  | start no earlier than 2009-10-03 | 13,565.21 |
| 20 | 2.4.3 | TRANSPORTE DE MATERIAL PROVENIENTE DE CANTERA PARA D <= 1KM |  | 126d | 2009-09-30 | 2010-04-28 | 9SS | 0d |  |  | 14,738.33 |
| 21 | 2.4.4 | TRANSPORTE DE MATERIAL PROVENIENTE DE CANTERA PARA D > 1KM |  | 126d | 2009-09-30 | 2010-04-28 | 9SS | 0d |  |  | 120,549.62 |
| 22 | 2.5 | **SEÑALIZACION Y SEGURIDAD VIAL** |  | 25d | 2010-04-03 | 2010-04-27 |  | 1d |  |  | 139,748.78 |
| 23 | 2.5.1 | PANEL DE SEÑAL PREVENTIVA |  | 1d | 2010-04-03 | 2010-04-03 |  | 1d | 0d | start no earlier than 2010-04-03 | 923.04 |
| 24 | 2.5.2 | PANEL DE SEÑAL REGLAMENTARIA |  | 1d | 2010-04-04 | 2010-04-04 | 23 | 1d | 0d | start no earlier than 2007-06-14 | 362.41 |
| 25 | 2.5.3 | PANEL DE SEÑAL INFORMATIVA |  | 1d | 2010-04-05 | 2010-04-05 | 24 | 1d | 0d | start no earlier than 2007-06-14 | 752.72 |
| 26 | 2.5.4 | PINTADO DE POSTE DE SEÑAL |  | 3d | 2010-04-06 | 2010-04-08 | 25 | 1d | 0d |  | 1,193.01 |
| 27 | 2.5.5 | REPOSICION DE POSTRE DE SEÑAL |  | 1d | 2010-04-09 | 2010-04-09 | 26 | 1d | 0d |  | 354.88 |
| 28 | 2.5.6 | MARCAS EN EL PAVIMENTO |  | 17d | 2010-04-10 | 2010-04-26 | 27 | 1d | 0d |  | 135,790.48 |
| 29 | 2.5.7 | REPOSICIÓN DE POSTES KILOMETRICOS |  | 1d | 2010-04-27 | 2010-04-27 | 28 | 1d |  |  | 372.24 |

| ID | WBS | Task | Type | Duration | Start | Finish | Predecessors | Total slack | Constraint | Cost |
| --- | --- | --- | --- | --- | --- | --- | --- | --- | --- | --- |
| 30 | 2.6 | **IMPACTO AMBIENTAL** |  | 11d | 2010-04-18 | 2010-04-28 |  | 0d |  | 27,106.23 |
| 31 | 2.6.1 | DEPÓSITO DE DESECHOS |  | 1d | 2010-04-18 | 2010-04-18 | 9FS-11d | 0d | start no earlier than 2007-09-03 | 1,596.26 |
| 32 | 2.6.2 | REACONDICIONAMIENTO DE AREAS |  | 10d | 2010-04-18 | 2010-04-27 | 31FS-1d | 0d |  | 11,500 |
| 33 | 2.6.3 | EDUCACION AMBIENTAL |  | 1d | 2010-04-28 | 2010-04-28 | 32 | 0d |  | 14,009.97 |
| 34 | 3 | FIN | milestone | 0d | 2010-04-27 | 2010-04-27 | 32 | 1d |  |  |
